# Subproyecto A3 : "Entrega de las Defensas Ribereñas del Río Lacramarca - Paquete 11 - R07"

Schedule from Primavera P6, 2024-11-01 to 2025-05-03, data date 2024-11-01.
Must finish by 2025-05-03

## Calendars

- SubProyecto A3: Mon-Sun 08:00-16:00.

## Resources

| Resource | Group |
| --- | --- |
| Operador Excavadora | labor |
| Excavadora | equipment |
| Tractor D8 | equipment |
| Volquete | equipment |
| Operador Tractor | labor |
| Operador Volquete | labor |
| Tractor D6 | equipment |
| Operador Rodillo | labor |
| Rodillo | equipment |
| Motoniveladora | equipment |
| Operador Motoniveladora | labor |

## Schedule

| ID | WBS | Activity | Duration | Start | Finish | Predecessors | Total float | Free float | Constraint |
| --- | --- | --- | --- | --- | --- | --- | --- | --- | --- |
|  | A | **HITOS** |  | 2024-11-01 | 2025-05-03 |  |  |  |  |
| H1 |  | INICIO DE PLAZO CONTRACTUAL - ACCESO AL SITIO (16 días calendario despues del KOM) | 0d | 2024-11-01 | 2024-11-01 |  | 0d |  | start on or after 2023-11-01 |
| H2 |  | INICIO DE EXCAVACION | 0d | 2024-11-06 | 2024-11-06 | H1 FS+5d | 0d |  |  |
| H3 |  | INICIO DE RELLENO DE DIQUE | 0d | 2024-11-22 | 2024-11-22 | 1.5.3.99 FS+3d | 162d |  |  |
| H4 |  | FIN DE PLAZO DE CONTRACTUAL - CULMINACION DE OBRAS | 0d | 2025-05-03 | 2025-05-03 | 1.2.11 | 0d |  |  |
|  | 1 | **DEFENSAS RIBEREÑAS** |  | 2024-11-01 | 2025-05-02 |  |  |  |  |
|  | 1 | **OBRAS PRELIMINARES** |  | 2024-11-01 | 2025-04-20 |  |  |  |  |
| 1.1.2 |  | INSTALACIONES PROVISIONALES PARA LA OBRA | 13d | 2024-11-01 | 2024-11-13 | H1 | 6d | 0d |  |
| 1.1.3 |  | MANTENIMIENTO DE TRÁNSITO Y SEGURIDAD VIAL | 159d | 2024-11-13 | 2025-04-20 | 1.2.1 FS-1d | 12d |  |  |
| 1.1.1 |  | CARTEL DE IDENTIFICACIÓN OBRA 4.80 x 3.60 m. | 5d | 2024-11-14 | 2024-11-18 | 1.2.1, H1 | 165d |  |  |
|  | 2 | **TRABAJOS PRELIMINARES** |  | 2024-11-01 | 2025-05-02 |  |  |  |  |
| 1.2.1 |  | MOVILIZACION DE EQUIPOS | 13d | 2024-11-01 | 2024-11-13 | H1 | 6d | 0d |  |
| 1.2.2 |  | TOPOGRAFÍA Y GEOREFERENCIACIÓN | 170d | 2024-11-01 | 2025-04-19 | 1.1.2 SS | 6d | 0d |  |
| 1.2.11 |  | DESMOVILIZACION DE EQUIPOS | 15d | 2025-04-18 | 2025-05-02 | 2.2.5.2 FF, 5.2 FF | 0d |  |  |
|  | 3 | **MEJORAMIENTO DE VÍAS EXISTENTES** |  | 2024-11-08 | 2024-12-02 |  |  |  |  |
|  | 1 | **MOVIMIENTO DE TIERRAS** |  | 2024-11-08 | 2024-12-02 |  |  |  |  |
| 1.3.1.1 |  | ROCE Y LIMPIEZA DE MALEZA | 4d | 2024-11-08 | 2024-11-11 | 1.2.2 SS+7d | 151d | 0d |  |
| 1.3.1.2 |  | MEJORAMIENTO DE VIAS EXISTENTES | 22d | 2024-11-11 | 2024-12-02 | 1.3.1.1 SS+3d | 151d | 0d |  |
|  | 2 | **REPOSICIÓN DE ESTRUCTURAS** |  | 2024-11-15 | 2024-11-23 |  |  |  |  |
| 1.3.2.1 |  | DEMOLICIÓN DE ESTRUCTURAS EXISTENTES | 3d | 2024-11-15 | 2024-11-17 | 1.3.1.2 SS+4d | 152d | 0d |  |
| 1.3.2.2 |  | REPOSICIÓN DE PASE DE AGUA TUBO HDPE Ø=18" | 3d | 2024-11-18 | 2024-11-20 | 1.3.2.1 | 152d | 0d |  |
| 1.3.2.3 |  | REPOSICIÓN DE PASE DE AGUA TUBO HDPE Ø=36" | 3d | 2024-11-18 | 2024-11-20 | 1.3.2.2 SS | 152d | 0d |  |
| 1.3.2.4 |  | SUMINISTRO Y MONTAJE DE PANELES DE C°A° 1.6mx1.0mx0.20m EN PASE DE AGUA | 3d | 2024-11-21 | 2024-11-23 | 1.3.2.3 | 152d | 0d |  |
| 1.3.2.5 |  | SUMINISTRO Y MONTAJE DE PANELES DE C°A° 2.20mx1.0mx0.20m EN PASE DE AGUA | 3d | 2024-11-21 | 2024-11-23 | 1.3.2.4 SS | 152d | 0d |  |

| ID | WBS | Activity | Duration | Start | Finish | Predecessors | Total float | Free float | Resources |
| --- | --- | --- | --- | --- | --- | --- | --- | --- | --- |
|  | 3 | **CABEZAL DE ENTRADA Y SALIDA** |  | 2024-11-24 | 2024-12-01 |  |  |  |  |
| 1.3.3.2 |  | ENCOFRADO Y DESENCOFRADO RECTO | 5d | 2024-11-24 | 2024-11-28 | 1.3.2.5 | 152d | 0d |  |
| 1.3.3.1 |  | CONCRETOS | 3d | 2024-11-29 | 2024-12-01 | 1.3.3.2 | 152d |  |  |
|  | 4 | **DESCOLMATACIÓN DE CAUCE y OBRAS AUXILIARES** |  | 2024-11-01 | 2025-04-23 |  |  |  |  |
| 1.4.1 |  | DESBROCE Y LIMPIEZA EN ZONA NO BOSCOSA | 43d | 2024-11-01 | 2024-12-13 | 1.2.1 SS | 6d | 0d | Operador Excavadora [426 h]; Excavadora [426 h]; Tractor D8 [487 h]; Volquete [1157 h]; Operador Tractor [487.46 h]; Operador Volquete [1157 h] |
| 1.4.2 |  | DESCOLMATACIÓN DE CAUCE NATURAL DEL RÍO LACRAMARCA | 43d | 2024-11-04 | 2024-12-16 | 1.4.1 SS+3d | 135d | 0d | Tractor D8 [1034 h]; Operador Tractor [1034 h] |
| 1.4.3 |  | CONFORMACIÓN DE DESVIO EN CAUCE DE RÍO | 40d | 2024-11-06 | 2024-12-15 | 1.4.2 SS+2d | 135d | 126d | Operador Excavadora [572 h]; Excavadora [572 h] |
| 1.4.4 |  | RELLENO NO ESTRUCTURAL CON MATERIAL PROPIO | 33d | 2025-03-22 | 2025-04-23 | 1.4.3 SS+10d, 1.5.1.5, 1.5.2.5 | 9d |  | Tractor D6 [459 h]; Operador Tractor [459 h] |
|  | 5 | **DIQUES DE TIERRA COMPACTADA CON ENROCADO** |  | 2024-11-06 | 2025-04-26 |  |  |  |  |
|  | 1 | **DIQUE DE TIERRA COMPACTADA A3-D-01** |  | 2024-12-15 | 2025-02-07 |  |  |  |  |
| 1.5.1.1 |  | EXCAVACIÓN EN TERRENO NATURAL CON EQUIPO | 7d | 2024-12-15 | 2024-12-21 | H2, 1.5.2.1, 1.5.2.2, 1.5.3.89 | 48d | 0d | Operador Excavadora [56 h]; Excavadora [56 h]; Tractor D6 [28 h]; Operador Tractor [28 h] |
| 1.5.1.2 |  | EXCAVACIÓN DE UÑA CON EQUIPO | 4d | 2024-12-22 | 2024-12-25 | 1.5.1.1 | 48d | 0d | Operador Excavadora [29 h]; Excavadora [29 h] |
| 1.5.1.3 |  | PERFILADO Y COMPACTACIÓN EN ZONA DE CORTE | 5d | 2024-12-26 | 2024-12-30 | 1.5.1.2 | 48d | 0d | Operador Rodillo [17 h]; Rodillo [17 h]; Motoniveladora [36 h]; Operador Motoniveladora [36 h] |
| 1.5.1.9 |  | PREPARACIÓN DE FUNDACIÓN DE CUERPO DE DIQUE | 3d | 2024-12-31 | 2025-01-02 | 1.5.1.3 | 48d | 0d | Operador Rodillo [7 h]; Rodillo [7 h]; Motoniveladora [7 h]; Operador Motoniveladora [7 h] |
| 1.5.1.4 |  | CONFORMACIÓN DE CUERPO DE DIQUE CON MATERIAL PROPIO | 5d | 2025-01-03 | 2025-01-07 | 1.5.1.9 | 48d | 0d | Operador Excavadora [39 h]; Excavadora [39 h]; Operador Rodillo [38 h]; Rodillo [38 h]; Motoniveladora [38 h]; Operador Motoniveladora [38 h] |
| 1.5.1.6 |  | GEOTEXTIL NO TEJIDO 400 G/M2, INC. COLOCACIÓN | 12d | 2025-01-08 | 2025-01-19 | 1.5.1.4 | 48d | 0d |  |
| 1.5.1.7 |  | COLOCACION Y ACOMODO DE ROCA EN UÑA DE DIQUE | 10d | 2025-01-12 | 2025-01-21 | 1.5.1.6 SS+4d | 48d | 0d | Operador Excavadora [447 h]; Excavadora [447 h] |
| 1.5.1.8 |  | COLOCACION Y ACOMODO DE ROCA EN TALUD DE DIQUE | 14d | 2025-01-19 | 2025-02-01 | 1.5.1.7 SS+7d | 48d | 0d | Operador Excavadora [682 h]; Excavadora [682 h] |
| 1.5.1.5 |  | CONFORMACIÓN DE CORONA DE DIQUE CON MATERIAL PROPIO | 6d | 2025-02-02 | 2025-02-07 | 1.5.1.8 | 51d | 42d | Operador Excavadora [24 h]; Excavadora [24 h]; Operador Rodillo [23 h]; Rodillo [23 h]; Motoniveladora [23 h]; Operador Motoniveladora [23 h] |
|  | 2 | **DIQUE DE TIERRA COMPACTADA A3-D-02** |  | 2024-11-07 | 2025-03-21 |  |  |  |  |
| 1.5.2.1 |  | EXCAVACIÓN EN TERRENO NATURAL CON EQUIPO | 26d | 2024-11-07 | 2024-12-02 | H2 FS+1d, 1.2.2 SS, 1.2.1 SS, 1.4.1 SS, H1 | 0d |  | Operador Excavadora [485 h]; Excavadora [485 h]; Tractor D6 [240 h]; Operador Tractor [240 h] |
| 1.5.2.2 |  | EXCAVACIÓN DE UÑA CON EQUIPO | 12d | 2024-11-28 | 2024-12-09 | 1.5.2.1 FS-5d | 0d |  | Operador Excavadora [206 h]; Excavadora [206 h] |
| 1.5.2.3 |  | PERFILADO Y COMPACTACIÓN EN ZONA DE CORTE | 11d | 2024-12-10 | 2024-12-20 | 1.5.2.2 | 0d |  | Operador Rodillo [105 h]; Rodillo [105 h]; Motoniveladora [223 h]; Operador Motoniveladora [223 h] |
| 1.5.2.9 |  | PREPARACIÓN DE FUNDACIÓN DE CUERPO DE DIQUE | 6d | 2024-12-21 | 2024-12-26 | 1.5.2.3 | 0d |  | Operador Rodillo [26 h]; Rodillo [26 h]; Motoniveladora [26 h]; Operador Motoniveladora [26 h] |
| 1.5.2.4 |  | CONFORMACIÓN DE CUERPO DE DIQUE CON MATERIAL PROPIO | 9d | 2024-12-24 | 2025-01-01 | 1.5.2.9 FS-3d | 0d |  | Operador Excavadora [164 h]; Excavadora [164 h]; Operador Rodillo [160 h]; Rodillo [160 h]; Motoniveladora [160 h]; Operador Motoniveladora [160 h] |
| 1.5.2.6 |  | GEOTEXTIL NO TEJIDO 400 G/M2, INC. COLOCACIÓN | 45d | 2024-12-31 | 2025-02-13 | 1.5.2.4 FS-2d | 0d |  |  |
| 1.5.2.7 |  | COLOCACION Y ACOMODO DE ROCA EN UÑA DE DIQUE | 57d | 2025-01-03 | 2025-02-28 | 1.5.2.6 SS+3d | 0d |  | Operador Excavadora [3210 h]; Excavadora [3210 h] |
| 1.5.2.8 |  | COLOCACION Y ACOMODO DE ROCA EN TALUD DE DIQUE | 48d | 2025-01-18 | 2025-03-06 | 1.5.2.7 SS+15d | 0d |  | Operador Excavadora [3908 h]; Excavadora [3908 h] |
| 1.5.2.5 |  | CONFORMACIÓN DE CORONA DE DIQUE CON MATERIAL PROPIO | 15d | 2025-03-07 | 2025-03-21 | 1.5.2.8 | 9d | 0d | Operador Excavadora [119 h]; Excavadora [119 h]; Operador Rodillo [116 h]; Rodillo [116 h]; Motoniveladora [116 h]; Operador Motoniveladora [116 h] |

| ID | WBS | Activity | Duration | Start | Finish | Predecessors | Total float | Free float | Resources |
| --- | --- | --- | --- | --- | --- | --- | --- | --- | --- |
|  | 3 | **DIQUE DE TIERRA COMPACTADA A3-I-01** |  | 2024-11-06 | 2025-03-01 |  |  |  |  |
|  | 1 | **DIQUE DE TIERRA COMPACTADA A3-I-01- 1 ETAPA** |  | 2024-11-06 | 2024-12-24 |  |  |  |  |
| 1.5.3.19 |  | EXCAVACIÓN EN TERRENO NATURAL CON EQUIPO | 7d | 2024-11-06 | 2024-11-12 | H2, H1 | 20d | 0d | Operador Excavadora [126 h]; Excavadora [126 h]; Tractor D6 [62 h]; Operador Tractor [62 h] |
| 1.5.3.29 |  | EXCAVACIÓN DE UÑA CON EQUIPO | 2d | 2024-11-13 | 2024-11-14 | 1.5.3.19 | 20d | 0d | Operador Excavadora [28 h]; Excavadora [28 h] |
| 1.5.3.39 |  | PERFILADO Y COMPACTACIÓN EN ZONA DE CORTE | 2d | 2024-11-15 | 2024-11-16 | 1.5.3.29 | 20d | 0d | Operador Rodillo [15 h]; Rodillo [15 h]; Motoniveladora [32 h]; Operador Motoniveladora [32 h] |
| 1.5.3.99 |  | PREPARACIÓN DE FUNDACIÓN DE CUERPO DE DIQUE | 2d | 2024-11-17 | 2024-11-18 | 1.5.3.39 | 20d | 0d | Operador Rodillo [9 h]; Rodillo [9 h]; Motoniveladora [9 h]; Operador Motoniveladora [9 h] |
| 1.5.3.49 |  | CONFORMACIÓN DE CUERPO DE DIQUE CON MATERIAL PROPIO | 4d | 2024-11-19 | 2024-11-22 | 1.5.3.99 | 20d | 0d | Operador Excavadora [66 h]; Excavadora [66 h]; Operador Rodillo [64 h]; Rodillo [64 h]; Motoniveladora [64 h]; Operador Motoniveladora [64 h] |
| 1.5.3.69 |  | GEOTEXTIL NO TEJIDO 400 G/M2, INC. COLOCACIÓN | 3d | 2024-11-23 | 2024-11-25 | 1.5.3.49 | 20d | 0d |  |
| 1.5.3.79 |  | COLOCACION Y ACOMODO DE ROCA EN UÑA DE DIQUE | 8d | 2024-11-26 | 2024-12-03 | 1.5.3.69 | 20d | 0d | Operador Excavadora [437 h]; Excavadora [437 h] |
| 1.5.3.89 |  | COLOCACION Y ACOMODO DE ROCA EN TALUD DE DIQUE | 11d | 2024-12-04 | 2024-12-14 | 1.5.3.79, 1.5.3.79 FF | 48d | 0d | Operador Excavadora [669 h]; Excavadora [669 h] |
| 1.5.3.59 |  | CONFORMACIÓN DE CORONA DE DIQUE CON MATERIAL PROPIO | 10d | 2024-12-15 | 2024-12-24 | 1.5.3.89 | 129d |  | Operador Excavadora [23 h]; Excavadora [23 h]; Operador Rodillo [23 h]; Rodillo [23 h]; Motoniveladora [23 h]; Operador Motoniveladora [23 h] |
|  | 2 | **DIQUE DE TIERRA COMPACTADA A3-I-01- 2 ETAPA** |  | 2025-01-27 | 2025-03-01 |  |  |  |  |
| 1.5.3.100 |  | LIBERACIÓN DE PREDIOS A3-I-01 | 0d | 2025-01-27 | 2025-01-27 | H1 FS+87d | 0d |  |  |
| 1.5.3.109 |  | EXCAVACIÓN EN TERRENO NATURAL CON EQUIPO | 5d | 2025-01-27 | 2025-01-31 | 1.5.3.100 | 0d |  | Operador Excavadora [126 h]; Excavadora [126 h]; Tractor D6 [62 h]; Operador Tractor [62 h] |
| 1.5.3.119 |  | EXCAVACIÓN DE UÑA CON EQUIPO | 3d | 2025-02-01 | 2025-02-03 | 1.5.3.109 | 0d |  | Operador Excavadora [28 h]; Excavadora [28 h] |
| 1.5.3.129 |  | PERFILADO Y COMPACTACIÓN EN ZONA DE CORTE | 2d | 2025-02-04 | 2025-02-05 | 1.5.3.119 | 0d |  | Operador Rodillo [15 h]; Rodillo [15 h]; Motoniveladora [32 h]; Operador Motoniveladora [32 h] |
| 1.5.3.189 |  | PREPARACIÓN DE FUNDACIÓN DE CUERPO DE DIQUE | 2d | 2025-02-06 | 2025-02-07 | 1.5.3.129 | 0d |  | Operador Rodillo [9 h]; Rodillo [9 h]; Motoniveladora [9 h]; Operador Motoniveladora [9 h] |
| 1.5.3.139 |  | CONFORMACIÓN DE CUERPO DE DIQUE CON MATERIAL PROPIO | 3d | 2025-02-08 | 2025-02-10 | 1.5.3.189 | 0d |  | Operador Excavadora [66 h]; Excavadora [66 h]; Operador Rodillo [64 h]; Rodillo [64 h]; Motoniveladora [64 h]; Operador Motoniveladora [64 h] |
| 1.5.3.159 |  | GEOTEXTIL NO TEJIDO 400 G/M2, INC. COLOCACIÓN | 5d | 2025-02-11 | 2025-02-15 | 1.5.3.139 | 0d |  |  |
| 1.5.3.169 |  | COLOCACION Y ACOMODO DE ROCA EN UÑA DE DIQUE | 5d | 2025-02-16 | 2025-02-20 | 1.5.3.159 | 0d |  | Operador Excavadora [437 h]; Excavadora [437 h] |
| 1.5.3.179 |  | COLOCACION Y ACOMODO DE ROCA EN TALUD DE DIQUE | 7d | 2025-02-21 | 2025-02-27 | 1.5.3.169, 1.5.3.169 FF | 0d |  | Operador Excavadora [669 h]; Excavadora [669 h] |
| 1.5.3.149 |  | CONFORMACIÓN DE CORONA DE DIQUE CON MATERIAL PROPIO | 2d | 2025-02-28 | 2025-03-01 | 1.5.3.179 | 62d |  | Operador Excavadora [23 h]; Excavadora [23 h]; Operador Rodillo [23 h]; Rodillo [23 h]; Motoniveladora [23 h]; Operador Motoniveladora [23 h] |
|  | 4 | **DIQUE DE TIERRA COMPACTADA A3-I-02** |  | 2024-11-06 | 2025-01-31 |  |  |  |  |
| 1.5.4.1 |  | EXCAVACIÓN EN TERRENO NATURAL CON EQUIPO | 25d | 2024-11-06 | 2024-11-30 | H2, H1 | 0d |  | Operador Excavadora [171 h]; Excavadora [171 h]; Tractor D6 [85 h]; Operador Tractor [85 h] |
| 1.5.4.2 |  | EXCAVACIÓN DE UÑA CON EQUIPO | 8d | 2024-12-01 | 2024-12-08 | 1.5.4.1 | 0d |  | Operador Excavadora [38 h]; Excavadora [38 h] |
| 1.5.4.3 |  | PERFILADO Y COMPACTACIÓN EN ZONA DE CORTE | 7d | 2024-12-09 | 2024-12-15 | 1.5.4.2 | 0d |  | Operador Rodillo [19 h]; Rodillo [19 h]; Motoniveladora [40 h]; Operador Motoniveladora [40 h] |
| 1.5.4.9 |  | PREPARACIÓN DE FUNDACIÓN DE CUERPO DE DIQUE | 3d | 2024-12-16 | 2024-12-18 | 1.5.4.3 | 0d |  | Operador Rodillo [4 h]; Rodillo [4 h]; Motoniveladora [4 h]; Operador Motoniveladora [4 h] |
| 1.5.4.4 |  | CONFORMACIÓN DE CUERPO DE DIQUE CON MATERIAL PROPIO | 4d | 2024-12-19 | 2024-12-22 | 1.5.4.9 | 0d |  | Operador Excavadora [14 h]; Excavadora [14 h]; Operador Rodillo [14 h]; Rodillo [14 h]; Motoniveladora [14 h]; Operador Motoniveladora [14 h] |
| 1.5.4.6 |  | GEOTEXTIL NO TEJIDO 400 G/M2, INC. COLOCACIÓN | 11d | 2024-12-23 | 2025-01-02 | 1.5.4.4 | 0d |  |  |
| 1.5.4.7 |  | COLOCACION Y ACOMODO DE ROCA EN UÑA DE DIQUE | 23d | 2024-12-26 | 2025-01-17 | 1.5.4.6 SS+3d | 0d |  | Operador Excavadora [596 h]; Excavadora [596 h] |
| 1.5.4.8 |  | COLOCACION Y ACOMODO DE ROCA EN TALUD DE DIQUE | 16d | 2025-01-10 | 2025-01-25 | 1.5.4.7 SS+15d | 0d |  | Operador Excavadora [750 h]; Excavadora [750 h] |
| 1.5.4.5 |  | CONFORMACIÓN DE CORONA DE DIQUE CON MATERIAL PROPIO | 6d | 2025-01-26 | 2025-01-31 | 1.5.4.8 | 91d |  | Operador Excavadora [28 h]; Excavadora [28 h]; Operador Rodillo [27 h]; Rodillo [27 h]; Motoniveladora [27 h]; Operador Motoniveladora [27 h] |

| ID | WBS | Activity | Duration | Start | Finish | Predecessors | Total float | Free float | Resources |
| --- | --- | --- | --- | --- | --- | --- | --- | --- | --- |
|  | 5 | **DIQUE DE TIERRA COMPACTADA A3-I-03** |  | 2024-11-06 | 2025-04-26 |  |  |  |  |
|  | 1 | **DIQUE DE TIERRA COMPACTADA A3-I-03- 1 ETAPA** |  | 2024-11-06 | 2025-03-07 |  |  |  |  |
| 1.5.5.19 |  | EXCAVACIÓN EN TERRENO NATURAL CON EQUIPO | 20d | 2024-11-06 | 2024-11-25 | H2, H1 | 56d | 0d | Operador Excavadora [315 h]; Excavadora [315 h]; Tractor D6 [155 h]; Operador Tractor [155 h] |
| 1.5.5.29 |  | EXCAVACIÓN DE UÑA CON EQUIPO | 12d | 2024-11-26 | 2024-12-07 | 1.5.5.19 | 56d | 0d | Operador Excavadora [170 h]; Excavadora [170 h] |
| 1.5.5.39 |  | PERFILADO Y COMPACTACIÓN EN ZONA DE CORTE | 11d | 2024-12-08 | 2024-12-18 | 1.5.5.29 | 56d | 0d | Operador Rodillo [85 h]; Rodillo [85 h]; Motoniveladora [181 h]; Operador Motoniveladora [181 h] |
| 1.5.5.99 |  | PREPARACIÓN DE FUNDACIÓN DE CUERPO DE DIQUE | 5d | 2024-12-19 | 2024-12-23 | 1.5.5.39 | 56d | 0d | Operador Rodillo [25 h]; Rodillo [25 h]; Motoniveladora [25 h]; Operador Motoniveladora [25 h] |
| 1.5.5.49 |  | CONFORMACIÓN DE CUERPO DE DIQUE CON MATERIAL PROPIO | 9d | 2024-12-22 | 2024-12-30 | 1.5.5.99 FS-2d | 56d | 0d | Operador Excavadora [133 h]; Excavadora [133 h]; Operador Rodillo [130 h]; Rodillo [130 h]; Motoniveladora [130 h]; Operador Motoniveladora [130 h] |
| 1.5.5.69 |  | GEOTEXTIL NO TEJIDO 400 G/M2, INC. COLOCACIÓN | 33d | 2024-12-31 | 2025-02-01 | 1.5.5.49 | 56d | 0d |  |
| 1.5.5.79 |  | COLOCACION Y ACOMODO DE ROCA EN UÑA DE DIQUE | 29d | 2025-01-03 | 2025-01-31 | 1.5.5.69 SS+3d | 56d | 0d | Operador Excavadora [2646 h]; Excavadora [2646 h] |
| 1.5.5.89 |  | COLOCACION Y ACOMODO DE ROCA EN TALUD DE DIQUE | 36d | 2025-01-18 | 2025-02-22 | 1.5.5.79 SS+15d | 56d | 0d | Operador Excavadora [3250 h]; Excavadora [3250 h] |
| 1.5.5.59 |  | CONFORMACIÓN DE CORONA DE DIQUE CON MATERIAL PROPIO | 13d | 2025-02-23 | 2025-03-07 | 1.5.5.89 | 56d |  | Operador Excavadora [97 h]; Excavadora [97 h]; Operador Rodillo [95 h]; Rodillo [95 h]; Motoniveladora [95 h]; Operador Motoniveladora [95 h] |
|  | 2 | **DIQUE DE TIERRA COMPACTADA A3-I-03- 2 ETAPA** |  | 2025-03-25 | 2025-04-26 |  |  |  |  |
| 1.5.5.109 |  | EXCAVACIÓN EN TERRENO NATURAL CON EQUIPO | 3d | 2025-03-25 | 2025-03-27 | 1.5.5.108 FS-1d | 6d | 0d | Operador Excavadora [315 h]; Excavadora [315 h]; Tractor D6 [155 h]; Operador Tractor [155 h] |
| 1.5.5.108 |  | LIBERACION DE PREDIOS A3-I-03 | 0d | 2025-03-26 | 2025-03-26 | H2 FS+140d | 6d | 0d |  |
| 1.5.5.119 |  | EXCAVACIÓN DE UÑA CON EQUIPO | 3d | 2025-03-28 | 2025-03-30 | 1.5.5.109 | 6d | 0d | Operador Excavadora [170 h]; Excavadora [170 h] |
| 1.5.5.129 |  | PERFILADO Y COMPACTACIÓN EN ZONA DE CORTE | 2d | 2025-03-31 | 2025-04-01 | 1.5.5.119 | 6d | 0d | Operador Rodillo [85 h]; Rodillo [85 h]; Motoniveladora [181 h]; Operador Motoniveladora [181 h] |
| 1.5.5.139 |  | CONFORMACIÓN DE CUERPO DE DIQUE CON MATERIAL PROPIO | 2d | 2025-04-02 | 2025-04-03 | 1.5.5.189 FS-2d | 6d | 0d | Operador Excavadora [133 h]; Excavadora [133 h]; Operador Rodillo [130 h]; Rodillo [130 h]; Motoniveladora [130 h]; Operador Motoniveladora [130 h] |
| 1.5.5.189 |  | PREPARACIÓN DE FUNDACIÓN DE CUERPO DE DIQUE | 2d | 2025-04-02 | 2025-04-03 | 1.5.5.129 | 6d | 0d | Operador Rodillo [25 h]; Rodillo [25 h]; Motoniveladora [25 h]; Operador Motoniveladora [25 h] |
| 1.5.5.159 |  | GEOTEXTIL NO TEJIDO 400 G/M2, INC. COLOCACIÓN | 5d | 2025-04-04 | 2025-04-08 | 1.5.5.139 | 6d | 0d |  |
| 1.5.5.169 |  | COLOCACION Y ACOMODO DE ROCA EN UÑA DE DIQUE | 4d | 2025-04-07 | 2025-04-10 | 1.5.5.159 SS+3d | 6d | 0d | Operador Excavadora [2646 h]; Excavadora [2646 h] |
| 1.5.5.179 |  | COLOCACION Y ACOMODO DE ROCA EN TALUD DE DIQUE | 3d | 2025-04-22 | 2025-04-24 | 1.5.5.169 SS+15d | 6d | 0d | Operador Excavadora [3250 h]; Excavadora [3250 h] |
| 1.5.5.149 |  | CONFORMACIÓN DE CORONA DE DIQUE CON MATERIAL PROPIO | 2d | 2025-04-25 | 2025-04-26 | 1.5.5.179 | 6d |  | Operador Excavadora [97 h]; Excavadora [97 h]; Operador Rodillo [95 h]; Rodillo [95 h]; Motoniveladora [95 h]; Operador Motoniveladora [95 h] |
|  | 6 | **RAMPAS** |  | 2025-02-23 | 2025-03-03 |  |  |  |  |
| 1.6.1 |  | EXCAVACIÓN EN TERRENO NATURAL CON EQUIPO | 3d | 2025-02-23 | 2025-02-25 | 1.5.5.89 | 60d | 0d | Operador Excavadora [5 h]; Excavadora [5 h]; Tractor D6 [3 h]; Operador Tractor [3 h] |
| 1.6.2 |  | CONFORMACIÓN DE CUERPO DE RAMPA CON MATERIAL PROPIO | 3d | 2025-02-26 | 2025-02-28 | 1.6.1 | 60d | 0d | Operador Excavadora [7 h]; Excavadora [7 h]; Operador Rodillo [7 h]; Rodillo [7 h]; Motoniveladora [7 h]; Operador Motoniveladora [7 h] |
| 1.6.3 |  | CONFORMACIÓN DE CORONACIÓN DE RAMPA | 3d | 2025-03-01 | 2025-03-03 | 1.6.2 | 60d |  | Operador Excavadora [5 h]; Excavadora [5 h]; Operador Rodillo [5 h]; Rodillo [5 h]; Motoniveladora [5 h]; Operador Motoniveladora [5 h] |

| ID | WBS | Activity | Duration | Start | Finish | Predecessors | Total float | Free float |
| --- | --- | --- | --- | --- | --- | --- | --- | --- |
|  | 2 | **OBRAS DE ARTE** |  | 2024-11-01 | 2025-05-02 |  |  |  |
|  | 1 | **CAPTACIÓN A3-CP-23-95** |  | 2025-01-18 | 2025-05-02 |  |  |  |
|  | 1 | **MOVIMIENTO DE TIERRAS** |  | 2025-01-18 | 2025-02-26 |  |  |  |
| 2.1.1.1 |  | EXCAVACIÓN ESTRUCTURAL PARA OBRAS DE ARTE | 8d | 2025-01-18 | 2025-01-25 | 1.5.2.8 SS | 0d |  |
| 2.1.1.2 |  | RELLENO ESTRUCTURAL PARA OBRAS DE ARTE, CON MATERIAL PROPIO | 5d | 2025-02-22 | 2025-02-26 | 2.1.2.2 | 65d |  |
|  | 2 | **OBRAS DE CONCRETO** |  | 2025-01-26 | 2025-02-21 |  |  |  |
| 2.1.2.3 |  | CONCRETO CICLÓPEO f'c=280 kg/cm2 + 30% P.G. | 3d | 2025-01-26 | 2025-01-28 | 2.1.1.1 | 0d |  |
| 2.1.2.1 |  | CONCRETO f'c=100 kg/cm2 | 3d | 2025-01-29 | 2025-01-31 | 2.1.2.3 | 0d |  |
| 2.1.2.5 |  | ACERO DE REFUERZO fy=4200 kg/cm2 | 11d | 2025-02-01 | 2025-02-11 | 2.1.2.1 | 0d |  |
| 2.1.2.4 |  | ENCOFRADO Y DESENCOFRADO RECTO | 7d | 2025-02-10 | 2025-02-16 | 2.1.2.5 FS-2d | 0d |  |
| 2.1.2.2 |  | CONCRETO f'c=280 kg/cm2 | 5d | 2025-02-17 | 2025-02-21 | 2.1.2.4 | 0d |  |
|  | 3 | **ESTRUCTURAS METALICAS** |  | 2025-02-22 | 2025-03-08 |  |  |  |
| 2.1.3.1 |  | COMPUERTA METALICA PLANA DESLIZANTE DE 1.0x1.0m | 3d | 2025-02-22 | 2025-02-24 | 2.1.2.2 | 55d | 0d |
| 2.1.3.2 |  | REJILLA DE 1.00x1.00m CON VARILLA DE 1/2" CADA 6,25cm | 3d | 2025-02-25 | 2025-02-27 | 2.1.3.1 | 55d | 0d |
| 2.1.3.3 |  | BARANDA DE FIERRO GALVANIZADO 1 1/2" | 3d | 2025-02-28 | 2025-03-02 | 2.1.3.2 | 55d | 0d |
| 2.1.3.4 |  | ESCALERA TIPO GATO | 3d | 2025-03-03 | 2025-03-05 | 2.1.3.3 | 55d | 0d |
| 2.1.3.5 |  | TAPA METALICA CIRCULAR DN600 MM | 3d | 2025-03-06 | 2025-03-08 | 2.1.3.4 | 55d |  |
|  | 4 | **TUBERIAS** |  | 2025-02-22 | 2025-04-19 |  |  |  |
| 2.1.4.1 |  | EXCAVACIÓN ESTRUCTURAL PARA OBRAS DE ARTE (Buzones) | 5d | 2025-02-22 | 2025-02-26 | 2.1.2.2 | 0d |  |
| 2.1.4.6 |  | CONCRETO f'c=100 kg/cm2 (Buzones) | 3d | 2025-02-27 | 2025-03-01 | 2.1.4.1 | 13d | 0d |
| 2.1.4.10 |  | ACERO DE REFUERZO fy=4200 kg/cm2 (Buzones) | 5d | 2025-03-02 | 2025-03-06 | 2.1.4.6 | 13d | 0d |
| 2.1.4.9 |  | ENCOFRADO Y DESENCOFRADO CURVO | 5d | 2025-03-05 | 2025-03-09 | 2.1.4.10 FS-2d | 13d | 0d |
| 2.1.4.8 |  | ENCOFRADO Y DESENCOFRADO RECTO | 4d | 2025-03-10 | 2025-03-13 | 2.1.4.9 | 13d | 0d |
| 2.1.4.7 |  | CONCRETO f'c=280 kg/cm2 (Buzones) | 3d | 2025-03-14 | 2025-03-16 | 2.1.4.8 | 13d | 0d |
| 2.1.4.2 |  | EXCAVACIÓN DE ZANJA | 13d | 2025-03-17 | 2025-03-29 | 2.1.4.7, 2.1.2.2 | 13d | 0d |
| 2.1.4.3 |  | RELLENO ESTRUCTURAL PARA OBRAS DE ARTE CON MATERIAL PROPIO (Buzones) | 3d | 2025-03-17 | 2025-03-19 | 2.1.4.7 | 44d |  |
| 2.1.4.4 |  | CAMA DE ARENA | 6d | 2025-03-30 | 2025-04-04 | 2.1.4.2 | 13d | 0d |
| 2.1.4.11 |  | SUMINISTRO E INSTALACIÓN DE TUBERÍA GRP DN600 mm SN2500 | 7d | 2025-04-05 | 2025-04-11 | 2.1.4.4 | 13d | 0d |
| 2.1.4.5 |  | RELLENO COMÚN PARA ZANJAS | 8d | 2025-04-12 | 2025-04-19 | 2.1.4.11 | 13d |  |

| ID | WBS | Activity | Duration | Start | Finish | Predecessors | Total float | Free float |
| --- | --- | --- | --- | --- | --- | --- | --- | --- |
|  | 5 | **CANAL** |  | 2025-02-27 | 2025-04-14 |  |  |  |
| 2.1.5.1 |  | EXCAVACIÓN ESTRUCTURAL PARA OBRAS DE ARTE | 8d | 2025-02-27 | 2025-03-06 | 2.1.1.1 FS+5d, 2.1.4.1 | 0d |  |
| 2.1.5.3 |  | COLOCACIÓN DE CONCRETO f'c=100 kg/cm2 | 4d | 2025-03-07 | 2025-03-10 | 2.1.5.1 | 0d |  |
| 2.1.5.6 |  | ACERO DE REFUERZO fy=4200 kg/cm2 | 13d | 2025-03-11 | 2025-03-23 | 2.1.5.3 | 0d |  |
| 2.1.5.5 |  | ENCOFRADO Y DESENCOFRADO RECTO | 12d | 2025-03-16 | 2025-03-27 | 2.1.5.6 SS+5d | 0d |  |
| 2.1.5.7 |  | JUNTA WATER STOP SIN BULBO 150 mm | 4d | 2025-03-28 | 2025-03-31 | 2.1.5.5 | 0d |  |
| 2.1.5.4 |  | COLOCACIÓN DE CONCRETO f'c=280 kg/cm2 | 5d | 2025-04-01 | 2025-04-05 | 2.1.5.7 | 0d |  |
| 2.1.5.2 |  | RELLENO ESTRUCTURAL PARA CANALES, CON MATERIAL PROPIO | 9d | 2025-04-06 | 2025-04-14 | 2.1.5.4 | 18d |  |
|  | 6 | **OBRAS DE DESCARGA** |  | 2025-04-05 | 2025-05-02 |  |  |  |
| 2.1.6.1 |  | EXCAVACIÓN ESTRUCTURAL PARA OBRAS DE ARTE | 6d | 2025-04-05 | 2025-04-10 | 2.1.5.4 FS-1d | 0d |  |
| 2.1.6.3 |  | CONCRETO f'c=100 kg/cm2 | 3d | 2025-04-11 | 2025-04-13 | 2.1.6.1 | 0d |  |
| 2.1.6.6 |  | ACERO DE REFUERZO fy=4200 kg/cm2 | 3d | 2025-04-14 | 2025-04-16 | 2.1.6.3 | 0d |  |
| 2.1.6.5 |  | ENCOFRADO Y DESENCOFRADO RECTO | 5d | 2025-04-17 | 2025-04-21 | 2.1.6.6 | 0d |  |
| 2.1.6.7 |  | JUNTA WATER STOP SIN BULBO 150 mm | 4d | 2025-04-19 | 2025-04-22 | 2.1.6.5 SS+2d | 0d |  |
| 2.1.6.4 |  | CONCRETO f'c=280 kg/cm2 | 3d | 2025-04-23 | 2025-04-25 | 2.1.6.7 | 0d |  |
| 2.1.6.2 |  | RELLENO ESTRUCTURAL PARA OBRAS DE ARTE CON MATERIAL PROPIO | 3d | 2025-04-26 | 2025-04-28 | 2.1.6.4 | 0d |  |
| 2.1.6.8 |  | COMPUERTA METALICA PLANA DESLIZANTE | 4d | 2025-04-29 | 2025-05-02 | 2.1.6.2 | 0d |  |
|  | 2 | **CAPTACIÓN A3-CP-21-05** |  | 2025-02-28 | 2025-05-02 |  |  |  |
|  | 1 | **MOVIMIENTO DE TIERRAS** |  | 2025-02-28 | 2025-04-03 |  |  |  |
| 2.2.1.1 |  | EXCAVACIÓN ESTRUCTURAL PARA OBRAS DE ARTE | 6d | 2025-02-28 | 2025-03-05 | 1.5.3.179 | 0d |  |
| 2.2.1.2 |  | RELLENO ESTRUCTURAL PARA OBRAS DE ARTE, CON MATERIAL PROPIO | 5d | 2025-03-30 | 2025-04-03 | 2.2.2.2 | 29d |  |
|  | 2 | **OBRAS DE CONCRETO** |  | 2025-03-06 | 2025-03-29 |  |  |  |
| 2.2.2.3 |  | CONCRETO CICLÓPEO f'c=280 kg/cm2 + 30% P.G. | 3d | 2025-03-06 | 2025-03-08 | 2.2.1.1 | 16d | 0d |
| 2.2.2.1 |  | CONCRETO f'c=100 kg/cm2 | 3d | 2025-03-09 | 2025-03-11 | 2.2.2.3 | 16d | 0d |
| 2.2.2.5 |  | ACERO DE REFUERZO fy=4200 kg/cm2 | 8d | 2025-03-12 | 2025-03-19 | 2.2.2.1 | 16d | 0d |
| 2.2.2.4 |  | ENCOFRADO Y DESENCOFRADO RECTO | 7d | 2025-03-16 | 2025-03-22 | 2.2.2.5 SS+4d | 16d | 0d |
| 2.2.2.2 |  | CONCRETO f'c=280 kg/cm2 | 7d | 2025-03-23 | 2025-03-29 | 2.2.2.4 | 16d | 0d |

| ID | WBS | Activity | Duration | Start | Finish | Predecessors | Total float | Free float |
| --- | --- | --- | --- | --- | --- | --- | --- | --- |
|  | 3 | **ESTRUCTURAS METALICAS** |  | 2025-03-30 | 2025-04-16 |  |  |  |
| 2.2.3.1 |  | COMPUERTA METALICA PLANA DESLIZANTE DE 1.0x1.0m | 3d | 2025-03-30 | 2025-04-01 | 2.2.2.2 | 16d | 0d |
| 2.2.3.2 |  | REJILLA DE 1.00x1.00m CON VARILLA DE 1/2 CADA 6,25cm | 3d | 2025-04-02 | 2025-04-04 | 2.2.3.1 | 16d | 0d |
| 2.2.3.3 |  | BARANDA DE FIERRO GALVANIZADO 1 1/2" | 6d | 2025-04-05 | 2025-04-10 | 2.2.3.2 | 16d | 0d |
| 2.2.3.4 |  | ESCALERA TIPO GATO | 3d | 2025-04-11 | 2025-04-13 | 2.2.3.3 | 16d | 0d |
| 2.2.3.5 |  | TAPA METALICA CIRCULAR DN600 MM | 3d | 2025-04-14 | 2025-04-16 | 2.2.3.4 | 16d |  |
|  | 4 | **TUBERIAS** |  | 2025-03-06 | 2025-04-08 |  |  |  |
| 2.2.4.1 |  | EXCAVACIÓN ESTRUCTURAL PARA OBRAS DE ARTE (Buzones) | 3d | 2025-03-06 | 2025-03-08 | 2.2.1.1 | 0d |  |
| 2.2.4.7 |  | CONCRETO f'c=100 kg/cm2 (Buzones) | 3d | 2025-03-09 | 2025-03-11 | 2.2.4.1 | 0d |  |
| 2.2.4.11 |  | ACERO DE REFUERZO fy=4200 kg/cm2 | 3d | 2025-03-12 | 2025-03-14 | 2.2.4.7 | 0d |  |
| 2.2.4.10 |  | ENCOFRADO Y DESENCOFRADO CURVO | 4d | 2025-03-15 | 2025-03-18 | 2.2.4.11 | 0d |  |
| 2.2.4.9 |  | ENCOFRADO Y DESENCOFRADO RECTO | 3d | 2025-03-19 | 2025-03-21 | 2.2.4.10 | 0d |  |
| 2.2.4.8 |  | CONCRETO f'c=280 kg/cm2 (Buzones) | 3d | 2025-03-22 | 2025-03-24 | 2.2.4.9 | 0d |  |
| 2.2.4.2 |  | EXCAVACIÓN DE ZANJA | 3d | 2025-03-25 | 2025-03-27 | 2.2.4.8, 2.2.1.1 | 0d |  |
| 2.2.4.3 |  | RELLENO ESTRUCTURAL PARA OBRAS DE ARTE CON MATERIAL PROPIO | 3d | 2025-03-25 | 2025-03-27 | 2.2.4.8 | 36d |  |
| 2.2.4.4 |  | CAMA DE ARENA | 3d | 2025-03-28 | 2025-03-30 | 2.2.4.2 | 0d |  |
| 2.2.4.12 |  | SUMINISTRO E INSTALACIÓN DE TUBERÍA GRP DN600 mm SN2500 | 3d | 2025-03-31 | 2025-04-02 | 2.2.4.4 | 0d |  |
| 2.2.4.6 |  | RELLENO COMÚN PARA ZANJAS | 3d | 2025-04-03 | 2025-04-05 | 2.2.4.12 | 24d | 0d |
| 2.2.4.5 |  | RELLENO SELECCIONADO PARA ZANJAS CON MATERIAL PROPIO | 3d | 2025-04-06 | 2025-04-08 | 2.2.4.6 | 24d |  |
|  | 5 | **CANALES** |  | 2025-04-03 | 2025-05-02 |  |  |  |
| 2.2.5.1 |  | EXCAVACIÓN ESTRUCTURAL PARA OBRAS DE ARTE | 6d | 2025-04-03 | 2025-04-08 | 2.2.4.12 | 0d |  |
| 2.2.5.3 |  | COLOCACIÓN DE CONCRETO f'c=100 kg/cm2 | 3d | 2025-04-09 | 2025-04-11 | 2.2.5.1 | 0d |  |
| 2.2.5.6 |  | ACERO DE REFUERZO fy=4200 kg/cm2 | 6d | 2025-04-12 | 2025-04-17 | 2.2.5.3 | 0d |  |
| 2.2.5.5 |  | ENCOFRADO Y DESENCOFRADO | 5d | 2025-04-16 | 2025-04-20 | 2.2.5.6 SS+4d | 0d |  |
| 2.2.5.7 |  | JUNTA WATER STOP SIN BULBO 150 mm | 3d | 2025-04-21 | 2025-04-23 | 2.2.5.5 | 0d |  |
| 2.2.5.4 |  | COLOCACIÓN DE CONCRETO f'c=280 kg/cm2 | 4d | 2025-04-24 | 2025-04-27 | 2.2.5.7 | 0d |  |
| 2.2.5.2 |  | RELLENO ESTRUCTURAL PARA CANALES, CON MATERIAL PROPIO | 5d | 2025-04-28 | 2025-05-02 | 2.2.5.4 | 0d |  |

| ID | WBS | Activity | Duration | Start | Finish | Predecessors | Total float | Free float |
| --- | --- | --- | --- | --- | --- | --- | --- | --- |
|  | 3 | **RETORNO A3-OA-RE-D-21-55** |  | 2025-02-02 | 2025-03-15 |  |  |  |
|  | 1 | **MOVIMIENTO DE TIERRAS** |  | 2025-02-02 | 2025-03-10 |  |  |  |
| 2.3.1.1 |  | EXCAVACIÓN ESTRUCTURAL PARA OBRAS DE ARTE | 3d | 2025-02-02 | 2025-02-04 | 1.5.1.8 | 48d | 0d |
| 2.3.1.2 |  | RELLENO ESTRUCTURAL PARA OBRAS DE ARTE, CON MATERIAL PROPIO | 3d | 2025-03-08 | 2025-03-10 | 2.3.2.2 | 48d | 0d |
|  | 2 | **OBRAS DE CONCRETO** |  | 2025-02-05 | 2025-03-07 |  |  |  |
| 2.3.2.3 |  | CONCRETO CICLÓPEO f'c=280 kg/cm2 + 30% P.G. | 4d | 2025-02-05 | 2025-02-08 | 2.3.1.1 | 48d | 0d |
| 2.3.2.1 |  | CONCRETO f'c=100 kg/cm2 | 3d | 2025-02-09 | 2025-02-11 | 2.3.2.3 | 48d | 0d |
| 2.3.2.5 |  | ACERO DE REFUERZO fy=4200 kg/cm2 | 13d | 2025-02-12 | 2025-02-24 | 2.3.2.1 | 48d | 0d |
| 2.3.2.4 |  | ENCOFRADO Y DESENCOFRADO | 6d | 2025-02-22 | 2025-02-27 | 2.3.2.5 FS-3d | 48d | 0d |
| 2.3.2.6 |  | JUNTA WATER STOP SIN BULBO 150 mm | 4d | 2025-02-28 | 2025-03-03 | 2.3.2.4 | 48d | 0d |
| 2.3.2.2 |  | CONCRETO f'c=280 kg/cm2 | 4d | 2025-03-04 | 2025-03-07 | 2.3.2.6 | 48d | 0d |
|  | 3 | **ESTRUCTURAS METALICAS** |  | 2025-03-11 | 2025-03-15 |  |  |  |
| 2.3.3.1 |  | COMPUERTA METALICA PLANA DESLIZANTE DE 1.0x1.6 m | 3d | 2025-03-11 | 2025-03-13 | 2.3.1.2 | 48d | 0d |
| 2.3.3.2 |  | BARANDA DE FIERRO GALVANIZADO 1 1/2" | 2d | 2025-03-14 | 2025-03-15 | 2.3.3.1 | 48d |  |
|  | 4 | **REPOSICIÓN DE CANALES** |  | 2024-11-01 | 2025-04-16 |  |  |  |
|  | 1 | **REPOSICIÓN DE CANAL 1** |  | 2025-01-26 | 2025-04-16 |  |  |  |
|  | 1 | **MOVIMIENTO DE TIERRAS** |  | 2025-01-26 | 2025-04-16 |  |  |  |
| 2.4.1.1.1 |  | DEMOLICIÓN DE ESTRUCTURAS EXISTENTES | 3d | 2025-01-26 | 2025-01-28 | 1.5.4.8 | 16d | 0d |
| 2.4.1.1.2 |  | EXCAVACIÓN EN TERRENO NATURAL CON EQUIPO | 7d | 2025-01-29 | 2025-02-04 | 2.4.1.1.1 | 16d | 0d |
| 2.4.1.1.3 |  | RELLENO ESTRUCTURAL PARA OBRAS DE ARTE CON MATERIAL PROPIO | 9d | 2025-04-08 | 2025-04-16 | 2.4.1.2.4 FS-3d | 16d |  |
|  | 2 | **OBRAS DE CONCRETO** |  | 2025-02-05 | 2025-04-13 |  |  |  |
| 2.4.1.2.3 |  | CONCRETO f'c=100 kg/cm2 | 7d | 2025-02-05 | 2025-02-11 | 2.4.1.1.2 | 16d | 0d |
| 2.4.1.2.2 |  | ACERO DE REFUERZO fy=4200 kg/cm2 | 28d | 2025-02-12 | 2025-03-11 | 2.4.1.2.3 | 16d | 0d |
| 2.4.1.2.1 |  | ENCOFRADO Y DESENCOFRADO RECTO | 32d | 2025-02-20 | 2025-03-23 | 2.4.1.2.2 SS+8d | 16d | 0d |
| 2.4.1.2.5 |  | JUNTA WATER STOP 6" | 8d | 2025-03-24 | 2025-03-31 | 2.4.1.2.1 | 16d | 0d |
| 2.4.1.2.4 |  | CONCRETO f'c=280 kg/cm2 | 10d | 2025-04-01 | 2025-04-10 | 2.4.1.2.5 | 16d | 0d |
| 2.4.1.2.6 |  | MAMPOSTERIA DE PIEDRA, e=20cm, ACABADO CARA VISTA | 3d | 2025-04-11 | 2025-04-13 | 2.4.1.2.4 | 19d |  |

| ID | WBS | Activity | Duration | Start | Finish | Predecessors | Total float | Free float |
| --- | --- | --- | --- | --- | --- | --- | --- | --- |
|  | 2 | **REPOSICIÓN DE CANAL 3** |  | 2024-11-01 | 2024-12-27 |  |  |  |
|  | 1 | **MOVIMIENTO DE TIERRAS** |  | 2024-11-01 | 2024-12-17 |  |  |  |
| 2.4.2.1.1 |  | DEMOLICIÓN DE ESTRUCTURAS EXISTENTES | 7d | 2024-11-01 | 2024-11-07 | H1 | 126d | 0d |
| 2.4.2.1.2 |  | EXCAVACIÓN EN TERRENO NATURAL CON EQUIPO | 3d | 2024-11-08 | 2024-11-10 | 2.4.2.1.1 | 126d | 0d |
| 2.4.2.1.3 |  | RELLENO ESTRUCTURAL PARA OBRAS DE ARTE CON MATERIAL PROPIO | 3d | 2024-12-15 | 2024-12-17 | 2.4.2.2.5 | 136d |  |
|  | 2 | **OBRAS DE CONCRETO** |  | 2024-11-11 | 2024-12-27 |  |  |  |
| 2.4.2.2.4 |  | CONCRETO f'c=100 kg/cm2 | 4d | 2024-11-11 | 2024-11-14 | 2.4.2.1.2 | 126d | 0d |
| 2.4.2.2.3 |  | MALLA ELECTROSOLDADA DE DN6mm EN CUADRICULA 15x15 cm | 9d | 2024-11-15 | 2024-11-23 | 2.4.2.2.4 | 126d | 0d |
| 2.4.2.2.1 |  | ENCOFRADO Y DESENCOFRADO PARA REVESTIMIENTO DE CANALES (CERCHAS) | 4d | 2024-11-23 | 2024-11-26 | 2.4.2.2.3 FS-1d | 126d | 0d |
| 2.4.2.2.2 |  | ENCOFRADO Y DESENCOFRADO RECTO | 13d | 2024-11-27 | 2024-12-09 | 2.4.2.2.1 | 126d | 0d |
| 2.4.2.2.5 |  | CONCRETO f'c=280 kg/cm2 | 5d | 2024-12-10 | 2024-12-14 | 2.4.2.2.2 | 126d | 0d |
| 2.4.2.2.6 |  | SELLO DE JUNTA CONSTRUCCIÓN CON MATERIAL ELASTOMÉRICO | 13d | 2024-12-15 | 2024-12-27 | 2.4.2.2.5 | 126d |  |
| 2.4.2.2.7 |  | MAMPOSTERIA DE PIEDRA, e=20cm, ACABADO CARA VISTA | 3d | 2024-12-15 | 2024-12-17 | 2.4.2.2.5 | 136d |  |
|  | 5 | **REPOSICIÓN SIFON INOPERATIVO** |  | 2024-11-12 | 2024-12-24 |  |  |  |
| 2.5.1 |  | DEMOLICIÓN DE ESTRUCTURAS EXISTENTES | 3d | 2024-11-12 | 2024-11-14 | H2 SS+6d | 44d | 0d |
| 2.5.2 |  | EXCAVACIÓN ESTRUCTURAL PARA OBRAS DE ARTE | 7d | 2024-11-15 | 2024-11-21 | 2.5.1 | 44d | 0d |
| 2.5.3 |  | COLOCACIÓN CAMA DE ARENA | 4d | 2024-11-22 | 2024-11-25 | 2.5.2 | 44d | 0d |
| 2.5.11 |  | CODOS HDPE DE 14" DN 355mm | 7d | 2024-11-26 | 2024-12-02 | 2.5.6 SS | 44d | 0d |
| 2.5.6 |  | TUBERÍAS DE 14" HDPE SDR21 DN 355mm | 7d | 2024-11-26 | 2024-12-02 | 2.5.3 | 44d | 0d |
| 2.5.5 |  | RELLENO COMÚN | 7d | 2024-12-03 | 2024-12-09 | 2.5.6, 2.5.11 | 44d | 0d |
| 2.5.4 |  | RELLENO ESTRUCTURAL PARA OBRAS DE ARTE CON MATERIAL PROPIO | 3d | 2024-12-10 | 2024-12-12 | 2.5.5 | 44d | 0d |
| 2.5.7 |  | CONCRETO f'c=100 kg/cm2 | 3d | 2024-12-13 | 2024-12-15 | 2.5.4 | 129d | 0d |
| 2.5.10 |  | ACERO DE REFUERZO fy=4200 kg/cm2 | 3d | 2024-12-16 | 2024-12-18 | 2.5.7 | 129d | 0d |
| 2.5.9 |  | ENCOFRADO Y DESENCOFRADO RECTO | 3d | 2024-12-19 | 2024-12-21 | 2.5.10 | 129d | 0d |
| 2.5.8 |  | CONCRETO f'c=280 kg/cm2 | 3d | 2024-12-22 | 2024-12-24 | 2.5.9 | 129d |  |

| ID | WBS | Activity | Duration | Start | Finish | Predecessors | Total float | Free float | Resources |
| --- | --- | --- | --- | --- | --- | --- | --- | --- | --- |
|  | 3 | **TRANSPORTE DE MATERIAL** |  | 2024-11-06 | 2025-04-20 |  |  |  |  |
| 3.5 |  | TRANSPORTE DE MATERIAL EXCEDENTE PARA DISTANCIAS <1KM | 130d | 2024-11-06 | 2025-03-15 | H2 | 10d | 0d | Volquete [4742 h]; Operador Volquete [4742 h] |
| 3.6 |  | TRANSPORTE DE MATERIAL EXCEDENTE PARA DISTANCIAS >1KM | 130d | 2024-11-06 | 2025-03-15 | 3.5 SS | 10d | 0d | Volquete [16442 h]; Operador Volquete [16442 h] |
| 3.3 |  | TRANSPORTE DE ROCA PARA DISTANCIAS <1KM | 130d | 2024-12-04 | 2025-04-12 | 1.5.3.79 | 20d | 0d | Volquete [3037 h]; Operador Volquete [3037 h] |
| 3.4 |  | TRANSPORTE DE ROCA PARA DISTANCIAS >1KM | 130d | 2024-12-04 | 2025-04-12 | 3.3 SS | 20d |  | Volquete [12197 h]; Operador Volquete [12197 h] |
| 3.1 |  | TRANSPORTE DE MATERIAL GRANULAR PARA DISTANCIAS <1KM | 85d | 2025-01-26 | 2025-04-20 | 2.1.2.3 SS | 12d |  | Volquete [372 h]; Operador Volquete [372 h] |
| 3.2 |  | TRANSPORTE DE MATERIAL GRANULAR PARA DISTANCIAS >1KM | 85d | 2025-01-26 | 2025-04-20 | 2.1.2.3 SS | 12d |  | Volquete [76.08 h]; Operador Volquete [76.08 h] |
|  | 4 | **ARQUITECTURA Y PAISAJISMO** |  | 2025-01-26 | 2025-03-26 |  |  |  |  |
|  | 1 | **OBRAS PRELIMINARES** |  | 2025-01-26 | 2025-02-05 |  |  |  |  |
| 4.1.1 |  | MOVILIZACIÓN Y DEMOVILIZACIÓN DE EQUIPOS Y HERRAMIENTAS (ARQUITECTURA Y PAISAJISMO) | 6d | 2025-01-26 | 2025-01-31 | 2.5.4, 1.5.4.8 | 0d |  |  |
| 4.1.2 |  | TRAZO Y REPLANTEO PRELIMINAR | 5d | 2025-02-01 | 2025-02-05 | 4.1.1 | 0d |  |  |
|  | 2 | **MOVIMIENTO DE TIERRAS** |  | 2025-02-06 | 2025-02-19 |  |  |  |  |
| 4.2.1 |  | EXCAVACIÓN MANUAL PARA INSTALACIÓN DE BORDILLOS Y CIMENTACIONES | 5d | 2025-02-06 | 2025-02-10 | 4.1.2 | 0d |  |  |
| 4.2.2 |  | EXCAVACIÓN PARA MEJORAMIENTO DE SUELO CON TIERRA VEGETAL | 8d | 2025-02-07 | 2025-02-14 | 4.2.1 SS+1d | 0d |  |  |
| 4.2.3 |  | ELIMINACION DE MATERIAL EXCEDENTE (DME´S) | 5d | 2025-02-15 | 2025-02-19 | 4.2.2 | 72d |  |  |
|  | 3 | **PAVIMENTOS, RECUBRIMIENTOS Y BORDILLOS** |  | 2025-02-15 | 2025-03-04 |  |  |  |  |
| 4.3.1 |  | PISO DE GRAVILLA | 3d | 2025-02-15 | 2025-02-17 | 4.2.2 | 0d |  |  |
| 4.3.2 |  | RECUBRIMIENTO DE PIEDRA DEL LUGAR e=0.05cm | 10d | 2025-02-18 | 2025-02-27 | 4.3.1 | 0d |  |  |
| 4.3.3 |  | BORDILLOS DE PIEDRA DEL LUGAR | 5d | 2025-02-28 | 2025-03-04 | 4.3.2 | 0d |  |  |
|  | 4 | **MOBILIARIOS, BARANDAS Y ESCALERAS** |  | 2025-03-05 | 2025-03-26 |  |  |  |  |
| 4.4.1 |  | ESCALERA DE CONCRETO SOBRE ENROCADO, CIMENTACION Y ANCLAJE | 4d | 2025-03-05 | 2025-03-08 | 4.3.3 | 0d |  |  |
| 4.4.2 |  | BARANDA DE MADERA EUCALIPTO CON SOGA, INCLUYE CIMENTACIÓN | 3d | 2025-03-09 | 2025-03-11 | 4.4.1 | 0d |  |  |
| 4.4.7 |  | BOLARDOS DE PIEDRA | 3d | 2025-03-12 | 2025-03-14 | 4.4.2 | 37d | 0d |  |
| 4.4.5 |  | POSTES DE ILUMINACIÓN, INCLUYE LUMINARIA Y CIMENTACIÓN | 3d | 2025-03-15 | 2025-03-17 | 4.4.7 | 37d | 0d |  |
| 4.4.4 |  | BANCAS DE CONCRETO, INCLUYE CIMENTACIÓN | 3d | 2025-03-18 | 2025-03-20 | 4.4.5 | 37d | 0d |  |
| 4.4.3 |  | TACHOS DE BASURA, INCLUYE CIMENTACIÓN | 3d | 2025-03-21 | 2025-03-23 | 4.4.4 | 37d | 0d |  |
| 4.4.6 |  | SEÑALETICA INFORMATIVA | 3d | 2025-03-24 | 2025-03-26 | 4.4.3 | 37d |  |  |

| ID | WBS | Activity | Duration | Start | Finish | Predecessors | Total float | Resources |
| --- | --- | --- | --- | --- | --- | --- | --- | --- |
|  | 5 | **INSTALACIÓN DE ALCORQUES** |  | 2025-03-05 | 2025-03-07 |  |  |  |
| 4.5.1 |  | ALCORQUES DE PIEDRA DE CANTO RODADO PARA ARBOLES | 3d | 2025-03-05 | 2025-03-07 | 4.3.3 | 56d |  |
|  | 5 | **PROGRAMA DE CIERRE DE OBRA** |  | 2024-11-09 | 2025-05-02 |  |  |  |
| 5.1 |  | ACONDICIONAMIENTO DE DEPOSITOS DE MATERIALES EXCEDENTES (DME) | 165d | 2024-11-09 | 2025-04-22 | 3.5 SS+3d, 3.6 SS+3d | 10d | Tractor D6 [1579 h]; Operador Tractor [1579 h] |
| 5.2 |  | RESTAURACIÓN DE ÁREAS DE INSTALACIONES PROVISIONALES | 45d | 2025-03-19 | 2025-05-02 | 4.4.2 FS+7d | 0d |  |
|  | 6 | **SEGURIDAD Y SALUD OCUPACIONAL** |  | 2024-11-01 | 2025-04-19 |  |  |  |
| 6.1 |  | SEGURIDAD Y SALUD OCUPACIONAL | 170d | 2024-11-01 | 2025-04-19 | H1 | 13d |  |
| 6.2 |  | IMPLEMENTACIÓN DEL PLAN PARA LA VIGILANCIA, PREVENCIÓN Y CONTROL DE COVID-19 EN EL TRABAJO | 160d | 2024-11-01 | 2025-04-09 | H1 | 23d |  |
